# Cronograma

Schedule from MS Project, 2009-06-01 to 2009-11-28, costs in S.

## Calendars

- Estándar: Mon-Sun 07:00-12:00, 13:00-16:00.

## Resources

| Resource | Group | Rate | Cost per use |
| --- | --- | --- | --- |
| TOPOGRAFO | Mano de Obra | 15.94 |  |
| NIVELADOR | Mano de Obra | 15.94 |  |
| OPERARIO | Mano de Obra | 12.75 |  |
| OFICIAL | Mano de Obra | 11.38 |  |
| PEON | Mano de Obra | 10.29 |  |
| CAPATAZ "B" | Mano de Obra | 15.3 |  |
| CAPATAZ "A" | Mano de Obra | 16.58 |  |
| MANO DE OBRA INC. LEYES SOCIALES | Mano de Obra | 8 |  |
| CLAVOS PARA MADERA C/C 3" | Material |  | 2.42 |
| ACERO CORRUGADO FY=4200 KG/CM2 GRADO 60 | Material |  | 2.51 |
| FILLER | Material |  | 0.72 |
| DERECHO DE EXPLOTACION DE MATERIAL DE CANTERA | Material |  | 5 |
| DERECHO DE USO DE DME | Material |  | 2 |
| EMULSION ASFALTICA MODIFICADA CON POLIMERO SBR | Material |  | 7.13 |
| EMULSION CATIONICA DE ROTURA RAPIDA CRS-2 | Material |  | 5.88 |
| CEMENTO ASFALTICO MODIFICADO CON POLIMERO SBS | Material |  | 2.4 |
| CEMENTO PORTLAND TIPO I (42.5KG) | Material |  | 17.81 |
| ADITIVO MEJORADOR DE ADHERENCIA | Material |  | 16.13 |
| CORDEL | Material |  | 0.5 |
| YESO DE 28 Kg | Material |  | 24.65 |
| PEGAMENTO EPOXICO UNIVERSAL | Material |  | 276.51 |
| GASOLINA | Material |  | 6.54 |
| MADERA TORNILLO | Material |  | 3.84 |
| PETROLEO | Material |  | 7.87 |
| LUBRICANTES FILTROS Y GRASAS | Material |  |  |
| PINTURA ESMALTE | Material |  | 28.89 |
| DILUYENTE DE PINTURA ESMALTE POLIURTEANO | Material |  | 59.91 |
| DILUYENTE ANTICORROSIVO | Material |  | 39.01 |
| PINTURA ESMALTE POLIURETANO (2 Mils) | Material |  | 320.91 |
| DISOLVENTE XILOL | Material |  | 19.8 |
| PINTURA DE TRAFICO | Material |  | 52.98 |
| MICROESFERAS DE VIDRIO | Material |  | 3.95 |
| TACHAS REFLECTORIZANTE | Material |  | 6.55 |
| MATERIALES | Material |  |  |
| MATERIALES | Material |  |  |
| HERRAMIENTAS MANUALES | Equipo | 8 |  |
| MOTOBOMBA 7-10 HP 3-4" | Equipo | 5.96 |  |
| VOLQUETE 15 M3 | Equipo | 220.76 |  |
| CAMION CISTERNA 4X2 (AGUA) 2 000GLN | Equipo | 128.62 |  |
| MAQUINA PARA PINTAR MARCAS EN PAVIMENTO | Equipo | 45 |  |
| COMPRESORA NEUMATICA 250-330 PCM 87 HP | Equipo | 63.52 |  |
| BARREDORA MECANICA 10-20 HP | Equipo | 39.69 |  |
| RODILLO LISO VIBR AUTOP 101-135HP 10-12T | Equipo | 137.08 |  |
| RODILLO NEUMATICO AUTOP 81-100HP 5.5-20T | Equipo | 117.88 |  |
| RODILLO TANDEM ESTATIC AUT 58-70HP 8-10T | Equipo | 54.49 |  |
| TRACTOR DE ORUGAS DE 190-240 HP | Equipo | 327.38 |  |
| CARGADOR S/LLANTAS 125 - 155 HP 3 YD3. | Equipo | 160.1 |  |
| CARGADOR S/LLANTAS 100-115 HP 2-2.35 YD3 | Equipo | 137.31 |  |
| ESPARCIDORA DE AGREGADOS | Equipo | 150 |  |
| ZARANDA VIBRATORIA 4"x6"x14" M.E. 15 HP | Equipo | 48.66 |  |
| TRACTOR DE TIRO DE 80 HP | Equipo | 62.56 |  |
| CHANCADORA PRIMARIA SECUNDARIA 5 FAJAS 75 HP 46-70 Ton/h | Equipo | 152.2 |  |
| MOTONIVELADORA DE 125 HP | Equipo | 149.3 |  |
| CAMIONETA PICK UP 4x2 84 HP | Equipo | 40.12 |  |
| CAMION IMPRIMADOR 210 HP 2 000 GLN | Equipo | 108.66 |  |
| GRUPO ELECTROGENO 116 HP 75 KW | Equipo | 95.1 |  |
| GRUPO ELECTROGENO 230 HP 150 KW | Equipo | 121.26 |  |
| SECADOR ARIDOS 2-M.E. 70HP 60-115 TON/H | Equipo | 45.7 |  |
| PAVIMENTADORA SOBRE ORUGAS | Equipo | 128.09 |  |
| PLANTA DE ASFALTO EN CALIENTE 150 TON/H | Equipo | 334.81 |  |
| CALENTADOR DE ACEITE 48 - S | Equipo | 21.7 |  |
| CAMION BARANDA 3 TON | Equipo | 63.4 |  |
| FAJA TRANSPORT 18"X50" M.E. 3HP 150 TON/H | Equipo | 6.52 |  |
| TEODOLITO | Equipo | 9.62 |  |
| NIVEL | Equipo | 7.77 |  |
| MAQUINARIA Y EQUIPO NACIONAL | Equipo | 8 |  |
| TRASLADO DE EQUIPO Y HERRAMIENTAS | Equipo | 8 |  |

## Schedule

| ID | WBS | Task | Duration | Start | Finish | Predecessors | Total slack | Free slack | Constraint | Resources | Work | Cost | Text1 | Text8 | Text3 | Text4 | Text2 | Text6 |
| --- | --- | --- | --- | --- | --- | --- | --- | --- | --- | --- | --- | --- | --- | --- | --- | --- | --- | --- |
| 1 | 1 | **MANTENIMIENTO PERIODICO DE LA CARRETERA PONTON QDA. SECA - PUENTE SANTA** | 180d | 2009-06-01 | 2009-11-28 |  | 0d |  |  |  | 1666666667h | 88,089,453.91 |  |  |  |  |  |  |
| 2 | 1.1 | **PRELIMINARES** | 180d | 2009-06-01 | 2009-11-28 |  | 0d |  |  |  | 5085.62h | 85,619.65 | 01 | 000000000000001 |  |  |  |  |
| 3 | 1.1.1 | MOVILIZACION Y DESMOVILIZACION DE EQUIPO | 45d | 2009-06-01 | 2009-11-27 |  | 0d |  | start no earlier than 2009-06-01 |  |  |  | 01.01 | 000000000000002 | 273833.85 | 273833.85 |  |  |
| 4 | 1.1.2 | TOPOGRAFIA Y GEOREFERENCIACION | 60d | 2009-06-16 | 2009-08-15 | 3SS+15d | 0d |  | start no earlier than 2009-06-01 | CEMENTO PORTLAND TIPO I (42.5KG) [11814%]; YESO DE 28 Kg [590.7%]; PINTURA ESMALTE [5907%]; TOPOGRAFO [99.3%]; NIVELADOR [99.3%]; PEON [595.7%]; CAPATAZ "B" [19.9%]; TEODOLITO [99.3%]; NIVEL [99.3%]; CLAVOS PARA MADERA C/C 3" [118.1%]; ACERO CORRUGADO FY=4200 KG/CM2 GRADO 60 [35442%]; CORDEL [2362.8%]; MADERA TORNILLO [318978%] | 4860.62h | 71,467.14 | 01.02 | 000000000000003 | 1080.58 | 127659.72 | 118.14 |  |
| 5 | 1.1.3 | MANTENIMIENTO DE TRANSITO Y SEGURIDAD VIAL | 165d | 2009-06-16 | 2009-11-28 | 4SS | 0d |  | start no earlier than 2009-06-01 |  |  |  | 01.03 | 000000000000004 | 311579.6 | 311579.6 |  |  |
| 6 | 1.1.4 | ACCESOS A CANTERAS, BOTADEROS Y FUENTES DE AGUA | 2d | 2009-06-21 | 2009-06-23 | 4SS+5d | 158d |  | start no earlier than 2009-06-01 | GASOLINA [600.6%]; PEON [564.1%]; CAPATAZ "B" [71.5%]; MOTOBOMBA 7-10 HP 3-4" [278.1%]; CAMION CISTERNA 4X2 (AGUA) 2 000GLN [278.1%]; RODILLO LISO VIBR AUTOP 101-135HP 10-12T [71.5%]; TRACTOR DE ORUGAS DE 190-240 HP [71.5%]; MOTONIVELADORA DE 125 HP [71.5%] | 225h | 14,152.51 | 01.04 | 000000000000005 | 9897.76 | 14153.8 | 1.43 |  |
| 7 | 1.2 | **PAVIMENTO ASFALTICO** | 120d | 2009-06-21 | 2009-10-19 |  | 0d |  |  |  | 1666666667h | 17,037,581.39 | 02 | 000000000000013 |  |  |  |  |
| 8 | 1.2.1 | RIEGO DE LIGA | 105d | 2009-06-21 | 2009-10-04 | 4SS+5d | 0d |  | start no earlier than 2009-06-01 | OFICIAL [101.3%]; PEON [600.4%]; CAPATAZ "A" [101.3%]; BARREDORA MECANICA 10-20 HP [101.3%]; TRACTOR DE TIRO DE 80 HP [101.3%]; CAMION IMPRIMADOR 210 HP 2 000 GLN [101.3%] | 9297.2h | 255,110.87 | 02.01 | 000000000000015 | 0.43 | 522587.63 | 1215320.07 | 5800 |
| 9 | 1.2.2 | TRATAMIENTO SUPERFICIAL SIMPLE | 45d | 2009-07-01 | 2009-08-15 | 8SS+10d | 0d |  | start no earlier than 2009-06-01 | PETROLEO [229656%]; FAJA TRANSPORT 18"X50" M.E. 3HP 150 TON/H [29.9%]; OPERARIO [70.5%]; OFICIAL [105.5%]; PEON [883.2%]; CAPATAZ "B" [10%]; CAPATAZ "A" [53.1%]; BARREDORA MECANICA 10-20 HP; RODILLO NEUMATICO AUTOP 81-100HP 5.5-20T; TRACTOR DE ORUGAS DE 190-240 HP [16.7%]; CARGADOR S/LLANTAS 125 - 155 HP 3 YD3. [11.9%]; CARGADOR S/LLANTAS 100-115 HP 2-2.35 YD3 [26.3%]; ESPARCIDORA DE AGREGADOS; ZARANDA VIBRATORIA 4"x6"x14" M.E. 15 HP [29.9%]; TRACTOR DE TIRO DE 80 HP; CHANCADORA PRIMARIA SECUNDARIA 5 FAJAS 75 HP 46-70 Ton/h [40.6%]; CAMION IMPRIMADOR 210 HP 2 000 GLN; GRUPO ELECTROGENO 116 HP 75 KW [29.9%]; GRUPO ELECTROGENO 230 HP 150 KW [40.6%]; DERECHO DE EXPLOTACION DE MATERIAL DE CANTERA [850579%] | 6645.27h | 371,927.54 | 02.02 | 000000000000104 | 1.93 | 684007.44 | 354408 | 4000 |
| 10 | 1.2.3 | PAVIMENTO DE CONCRETO ASFALTICO CALIENTE CON POLIMERO SBS | 65d | 2009-08-15 | 2009-10-19 | 9 | 0d |  | start no earlier than 2009-06-01 | PETROLEO; FAJA TRANSPORT 18"X50" M.E. 3HP 150 TON/H [284.7%]; OPERARIO [1043.4%]; OFICIAL [790.6%]; PEON [4089.7%]; CAPATAZ "B" [116.7%]; CAPATAZ "A" [53.4%]; VOLQUETE 15 M3 [1748.3%]; RODILLO NEUMATICO AUTOP 81-100HP 5.5-20T; RODILLO TANDEM ESTATIC AUT 58-70HP 8-10T; TRACTOR DE ORUGAS DE 190-240 HP [116.3%]; CARGADOR S/LLANTAS 125 - 155 HP 3 YD3. [83.1%]; CARGADOR S/LLANTAS 100-115 HP 2-2.35 YD3 [740.8%]; ZARANDA VIBRATORIA 4"x6"x14" M.E. 15 HP [284.7%]; CHANCADORA PRIMARIA SECUNDARIA 5 FAJAS 75 HP 46-70 Ton/h [459.2%]; GRUPO ELECTROGENO 116 HP 75 KW [284.7%]; GRUPO ELECTROGENO 230 HP 150 KW [559%]; SECADOR ARIDOS 2-M.E. 70HP 60-115 TON/H; PAVIMENTADORA SOBRE ORUGAS; PLANTA DE ASFALTO EN CALIENTE 150 TON/H; CALENTADOR DE ACEITE 48 - S; DERECHO DE EXPLOTACION DE MATERIAL DE CANTERA | 58519.3h | 5,249,453.88 | 02.03 | 000000000000023 | 198.18 | 4523284.1 | 22824.12 | 423 |
| 11 | 1.2.4 | CEMENTO ASFALTICO MODIFICADO CON POLIMEROS SBS | 65d | 2009-08-15 | 2009-10-19 | 10SS | 40d |  | start no earlier than 2009-06-01 | CEMENTO ASFALTICO MODIFICADO CON POLIMERO SBS | 1666666667h | 7,692,307.69 | 02.04 | 000000000000025 | 2.4 | 8189293.42 | 3412205.59 |  |
| 12 | 1.2.5 | EMULSION ASFALTICA DE ROTURA RAPIDA CRS-2 | 94d | 2009-06-21 | 2009-09-23 | 8SS | 66d |  | start no earlier than 2009-06-01 | EMULSION CATIONICA DE ROTURA RAPIDA CRS-2 | 162574038h | 1,271,190.61 | 02.05 | 000000000000105 | 5.88 | 1271190.61 | 216188.88 |  |
| 13 | 1.2.6 | EMULSION ASFALTICA MODIFICADA CON POLIMERO SBR | 65d | 2009-08-10 | 2009-10-14 | 8SS+50d | 45d |  | start no earlier than 2009-06-01 | EMULSION ASFALTICA MODIFICADA CON POLIMERO SBR | 85058111h | 1,166,277.56 | 02.06 | 000000000000027 | 7.13 | 1166277.56 | 163573.29 |  |
| 14 | 1.2.7 | FILLER MINERAL (CAL HIDRATADA) | 65d | 2009-08-15 | 2009-10-19 | 10SS | 40d |  | start no earlier than 2009-06-01 | FILLER | 545952893h | 755,934.78 | 02.07 | 000000000000030 | 0.72 | 755934.78 | 1049909.41 |  |
| 15 | 1.2.8 | ADITIVO MEJORADOR DE ADHERENCIA | 65d | 2009-08-15 | 2009-10-19 | 10SS | 40d |  | start no earlier than 2009-06-01 | ADITIVO MEJORADOR DE ADHERENCIA | 8877669h | 275,378.46 | 02.08 | 000000000000031 | 16.13 | 275378.46 | 17072.44 |  |
| 16 | 1.3 | **TRANSPORTE** | 110d | 2009-07-01 | 2009-10-19 |  | 40d |  |  |  | 319888h | 70,463,712.03 | 03 | 000000000000039 |  |  |  |  |
| 17 | 1.3.1 | TRANSPORTE DE MATERIAL GRANULAR MENOR A 1KM. | 89d | 2009-07-01 | 2009-09-28 | 9SS | 57d | 0d | start no earlier than 2009-06-01 | OFICIAL [48.7%]; VOLQUETE 15 M3 [97.5%]; CARGADOR S/LLANTAS 100-115 HP 2-2.35 YD3 [48.7%] | 1387.86h | 204,782.47 | 03.01 | 000000000000106 | 6.5 | 46073.04 | 7088.16 | 363 |
| 18 | 1.3.2 | TRANSPORTE DE MATERIAL GRANULAR MAYOR A 1KM. | 89d | 2009-07-01 | 2009-09-28 | 17SS | 57d | 0d | start no earlier than 2009-06-01 | VOLQUETE 15 M3 | 710.89h | 156,936.33 | 03.02 | 000000000000107 | 1.15 | 372726.32 | 324109.84 | 1538 |
| 19 | 1.3.3 | TRANSPORTE DE MEZCLA ASFALTICA MENOR A 1KM. | 65d | 2009-08-15 | 2009-10-19 | 10SS | 40d | 0d | start no earlier than 2009-06-01 | OFICIAL [48.7%]; VOLQUETE 15 M3 [98.1%] | 763.42h | 115,466.58 | 03.03 | 000000000000101 | 3.73 | 85133.97 | 22824.12 | 485 |
| 20 | 1.3.4 | TRANSPORTE DE MEZCLA ASFALTICA MAYOR A 1KM. | 65d | 2009-08-15 | 2009-10-19 | 19SS | 40d |  | start no earlier than 2009-06-01 | VOLQUETE 15 M3 [60966.4%] | 317025h | 69,986,526.64 | 03.04 | 000000000000102 | 1.48 | 1077376.79 | 727957.29 | 1188 |
| 21 | 1.4 | **SEÑALIZACION Y SEGURIDAD VIAL** | 40d | 2009-10-19 | 2009-11-28 |  | 0d |  |  |  | 3350.53h | 490,156.34 | 04 | 000000000000046 |  |  |  |  |
| 22 | 1.4.1 | TACHA RETROREFLECTIVA | 15d | 2009-11-13 | 2009-11-28 | 24 | 0d |  | start no earlier than 2009-06-01 | PEGAMENTO EPOXICO UNIVERSAL [5193%]; OPERARIO [192.2%]; OFICIAL [96.3%]; PEON [192.2%]; CAPATAZ "B" [19.1%]; CAMIONETA PICK UP 4x2 84 HP [96.3%]; TACHAS REFLECTORIZANTE [346200%] | 715.34h | 48,651.02 | 04.01 | 000000000000067 | 13.43 | 46494.66 | 3462 | 300 |
| 23 | 1.4.2 | **SEÑALIZACION HORIZONTAL** | 25d | 2009-10-19 | 2009-11-13 |  | 0d |  |  |  | 2635.19h | 441,505.32 | 04.02 | 000000000000068 |  |  |  |  |
| 24 | 1.4.2.1 | MARCAS EN EL PAVIMENTO | 25d | 2009-10-19 | 2009-11-13 | 10 | 0d |  | start no earlier than 2009-06-01 | DISOLVENTE XILOL [31414%]; PINTURA DE TRAFICO [439011%]; OPERARIO [196.3%]; OFICIAL [294.5%]; PEON [589%]; CAPATAZ "B" [19.6%]; MAQUINA PARA PINTAR MARCAS EN PAVIMENTO [98.2%]; CAMION BARANDA 3 TON [98.2%]; MICROESFERAS DE VIDRIO | 2591.66h | 338,810.7 | 04.02.01 | 000000000000069 | 9.83 | 385999.92 | 39267.54 | 800 |
| 25 | 1.4.2.2 | PINTADO DE REDUCIDORES DE VELOCIDAD | 2d | 2009-10-19 | 2009-10-21 | 24SS | 38d | 0d | start no earlier than 2009-06-01 | DILUYENTE DE PINTURA ESMALTE POLIURTEANO [18140.5%]; DILUYENTE ANTICORROSIVO [18140.5%]; PINTURA ESMALTE POLIURETANO (2 Mils) [25915%]; OPERARIO [64.8%]; PEON [64.8%]; CAPATAZ "B" [13%]; COMPRESORA NEUMATICA 250-330 PCM 87 HP [64.8%]; CAMION BARANDA 3 TON [64.8%] | 43.54h | 102,694.61 | 04.02.02 | 000000000000072 | 99.08 | 102706.33 | 1036.6 | 800 |

| ID | WBS | Task | Type | Duration | Start | Finish | Predecessors | Total slack | Free slack | Constraint | Resources | Work | Cost | Text1 | Text8 | Text3 | Text4 | Text2 | Text6 |
| --- | --- | --- | --- | --- | --- | --- | --- | --- | --- | --- | --- | --- | --- | --- | --- | --- | --- | --- | --- |
| 26 | 1.5 | **PROTECCION AMBIENTAL** |  | 156d | 2009-06-16 | 2009-11-19 |  | 9d |  |  |  | 151.5h | 12,384.5 | 05 | 000000000000088 |  |  |  |  |
| 27 | 1.5.1 | **MITIGACION AMBIENTAL** |  | 1d | 2009-10-19 | 2009-10-20 |  | 39d |  |  |  |  |  | 05.01 | 000000000000089 |  |  |  |  |
| 28 | 1.5.1.1 | SEÑALIZACION AMBIENTAL |  | 1d | 2009-10-19 | 2009-10-20 | 25SS | 39d |  | start no earlier than 2009-06-01 |  |  |  | 05.01.01 | 000000000000090 | 1100 | 6600 |  |  |
| 29 | 1.5.2 | **IMPLEMENTACION PMA, EDUCACION Y CAPACITACION AMBIENTAL** |  | 156d | 2009-06-16 | 2009-11-19 |  | 9d |  |  |  |  |  | 05.02 | 000000000000091 |  |  |  |  |
| 30 | 1.5.2.1 | CAPACITACION AL PERSONAL DE OBRA |  | 150d | 2009-06-16 | 2009-11-13 | 4SS | 9d | 0d | start no earlier than 2009-06-01 |  |  |  | 05.02.01 | 000000000000092 | 4500 | 4500 |  |  |
| 31 | 1.5.2.2 | CAPACITACION AL PUBLICO EN GRAL. |  | 3d | 2009-06-16 | 2009-11-19 | 30SS | 9d |  | start no earlier than 2009-06-01 |  |  |  | 05.02.02 | 000000000000093 | 6000 | 6000 |  |  |
| 32 | 1.5.2.3 | CAPACITACION A FUNCIONARIOS, PERSONAL PROFESIONAL Y TECNICO |  | 4d | 2009-06-30 | 2009-10-25 | 31SS | 33.88d |  | start no earlier than 2009-06-30 |  |  |  | 05.02.03 | 000000000000094 | 3000 | 3000 |  |  |
| 33 | 1.5.3 | **PROGRAMA DE ABANDONO DE OBRA** |  | 4d | 2009-09-28 | 2009-10-02 |  | 57d |  |  |  | 151.5h | 12,384.5 | 05.04 | 000000000000097 |  |  |  |  |
| 34 | 1.5.3.1 | ACONDICIONAMIENTO DE DEPOSITOS DE MATERIAL EXCEDENTE - DME |  | 1d | 2009-09-30 | 2009-10-01 | 35 | 58d |  | start no earlier than 2009-06-01 | PEON [33.6%]; CAPATAZ "B" [3.5%]; TRACTOR DE ORUGAS DE 190-240 HP [33.6%]; DERECHO DE USO DE DME [100000%] | 5.66h | 2,912.12 | 05.04.01 | 000000000000103 | 4.27 | 4270 | 1000 | 1200 |
| 35 | 1.5.3.2 | READECUACION AMBIENTAL DE CANTERAS, PLANTAS DE CHANCADO Y DE ASFALTO |  | 2d | 2009-09-28 | 2009-09-30 | 17, 18 | 57d | 0d | start no earlier than 2009-06-01 | GASOLINA [120%]; PEON [243.1%]; CAPATAZ "A" [62.5%]; MOTOBOMBA 7-10 HP 3-4" [55.6%]; CAMION CISTERNA 4X2 (AGUA) 2 000GLN [55.6%]; TRACTOR DE ORUGAS DE 190-240 HP [62.5%] | 76.67h | 5,044.04 | 05.04.02 | 000000000000099 | 2.03 | 5075 | 2500 | 2000 |
| 36 | 1.5.3.3 | READECUACION AMBIENTAL DE CAMPAMENTOS, ALMACENES Y PATIO DE MAQUINAS |  | 2d | 2009-09-30 | 2009-10-02 | 35 | 57d |  | start no earlier than 2009-06-01 | GASOLINA [120%]; PEON [268.1%]; MOTOBOMBA 7-10 HP 3-4" [55.6%]; CAMION CISTERNA 4X2 (AGUA) 2 000GLN [55.6%]; TRACTOR DE ORUGAS DE 190-240 HP [53.1%] | 69.17h | 4,428.33 | 05.04.03 | 000000000000100 | 1.77 | 4425 | 2500 | 2350 |
| 37 | 1.6 | FIN DE OBRA | milestone | 0d | 2009-11-28 | 2009-11-28 | 22, 3 | 0d |  |  |  |  |  |  |  |  |  |  |  |
